# Mechanical Tasks April24

Schedule from MS Project, 2006-04-18 to 2006-07-21.
MBARI

## Calendars

- Standard: Mon-Fri 08:00-12:00, 13:00-17:00; Sat-Sun off.

## Resources

| Resource |
| --- |
| D |
| Doug |
| John |
| Brett |
| Fred |
| Jon |
| S |
| Machine Shop |
| Ed |
| Jim |
| Paul |
| Andy |
| -+ |

## Schedule

| ID | WBS | Task | Type | Duration | Start | Finish | Predecessors | Total slack | Free slack | Constraint | Resources | Work |
| --- | --- | --- | --- | --- | --- | --- | --- | --- | --- | --- | --- | --- |
| 1 | 1 | **Rover Mechanical Tasks** |  | 61d? | 2006-04-18 | 2006-07-11 |  | 4d |  |  |  | 491h |
| 2 | 1.1 | **Weight drop** |  | 27.5d? | 2006-04-24 | 2006-05-31 |  | 36d |  |  |  | 36h |
| 3 | 1.1.1 | Modify weight drop assembly |  | 8d | 2006-04-24 | 2006-05-04 |  | 35.5d | 0d |  | John [25%] | 16h |
| 4 | 1.1.2 | order iron rod and hoops |  | 1d? | 2006-05-04 | 2006-05-05 | 3 | 36.5d | 0d |  | Brett [50%] | 4h |
| 5 | 1.1.3 | ship material |  | 10d | 2006-05-05 | 2006-05-19 | 4 | 36.5d | 0d |  |  |  |
| 6 | 1.1.4 | Cut rod and hoops |  | 2d? | 2006-05-19 | 2006-05-23 | 5 | 36.5d | 0d |  | John [25%] | 4h |
| 7 | 1.1.5 | weld hoops to weights |  | 2d? | 2006-05-23 | 2006-05-25 | 6 | 36.5d | 0d |  | John [25%] | 4h |
| 8 | 1.1.6 | Install weight |  | 4d? | 2006-05-25 | 2006-05-31 | 7 | 36.5d |  |  | John [25%] | 8h |
| 9 | 1.2 | **Track tensioner** |  | 22d? | 2006-04-24 | 2006-05-23 |  | 42d |  |  |  | 20h |
| 10 | 1.2.1 | Fabricate Ti springs |  | 2d? | 2006-04-24 | 2006-04-25 |  | 62d |  |  | Fred | 16h |
| 11 | 1.2.2 | Receive springs from SIO | milestone | 0d | 2006-05-22 | 2006-05-22 |  | 43.5d | 0d | start no earlier than 2006-05-22 |  |  |
| 12 | 1.2.3 | Install springs and test |  | 2d? | 2006-05-22 | 2006-05-23 | 11 | 42d |  |  | John [25%] | 4h |
| 13 | 1.3 | **Argos transmitter** |  | 52d? | 2006-04-24 | 2006-07-04 |  | 12d |  |  |  | 8h |
| 14 | 1.3.1 | set up account |  | 1d? | 2006-04-24 | 2006-04-25 |  | 62.5d |  |  | Brett [50%] | 4h |
| 15 | 1.3.2 | Design and build a bracket |  | 2d? | 2006-07-03 | 2006-07-04 | 70 | 12d |  |  | John [25%] | 4h |
| 16 | 1.4 | **Spar Buoy** |  | 29d? | 2006-04-24 | 2006-06-01 |  | 35d |  |  |  | 96h |
| 17 | 1.4.1 | Update model with SIO Spar Buoy components |  | 1d? | 2006-04-24 | 2006-04-25 |  | 62.5d |  |  | Brett [50%] | 4h |
| 18 | 1.4.2 | ship components from SIO to MBARI |  | 10d? | 2006-05-15 | 2006-05-26 |  | 38d | 0d | start no earlier than 2006-05-15 | Fred | 80h |
| 19 | 1.4.3 | Assemble spar buoy assembly |  | 4d? | 2006-05-29 | 2006-06-01 | 18 | 35d |  |  | John [25%] | 8h |
| 20 | 1.4.4 | confirm Atlantis can receive 159.480 MHz |  | 0.25d? | 2006-04-24 | 2006-04-24 |  | 63.75d |  |  | Brett | 2h |
| 21 | 1.4.5 | order connector rope |  | 0.5d? | 2006-04-24 | 2006-04-24 |  | 63.5d |  |  | Brett [50%] | 2h |
| 22 | 1.5 | **Oil compensator** |  | 20d? | 2006-05-01 | 2006-05-26 |  | 25d |  |  |  | 12h |
| 23 | 1.5.1 | Fabricate parts |  | 14d | 2006-05-01 | 2006-05-18 |  | 25d | 0d | start no earlier than 2006-05-01 |  |  |
| 24 | 1.5.2 | Build up, fill and test |  | 2d? | 2006-05-19 | 2006-05-22 | 23, 3 | 25d | 0d |  | John [25%] | 4h |
| 25 | 1.5.3 | Assemble plumbing |  | 2d? | 2006-05-23 | 2006-05-24 | 24 | 25d | 0d |  | John [25%] | 4h |
| 26 | 1.5.4 | Mount on Rover |  | 2d? | 2006-05-25 | 2006-05-26 | 25 | 25d | 0d |  | John [25%] | 4h |

| ID | WBS | Task | Duration | Start | Finish | Predecessors | Total slack | Free slack | Constraint | Resources | Work |
| --- | --- | --- | --- | --- | --- | --- | --- | --- | --- | --- | --- |
| 27 | 1.6 | **Shipboard cradle** | 10d? | 2006-05-29 | 2006-06-09 |  | 25d |  |  |  | 27h |
| 28 | 1.6.1 | Design cradle | 0.5d? | 2006-05-29 | 2006-05-29 | 26 | 25d | 0d |  | Brett; John | 8h |
| 29 | 1.6.2 | order parts | 1.5d? | 2006-05-29 | 2006-05-30 | 28 | 25d | 0d |  | John [25%] | 3h |
| 30 | 1.6.3 | fabricate and install | 8d? | 2006-05-31 | 2006-06-09 | 29 | 25d | 0d |  | John [25%] | 16h |
| 31 | 1.7 | CDR prep | 2d? | 2006-04-24 | 2006-04-26 |  | 61.5d |  |  | Brett [50%] | 8h |
| 32 | 1.8 | **Pressure Housings** | 46.5d? | 2006-04-18 | 2006-06-21 |  | 4d |  |  |  | 228h |
| 33 | 1.8.1 | **Battery Sphere** | 43d? | 2006-04-18 | 2006-06-15 |  | 25d |  |  |  | 32h |
| 34 | 1.8.1.1 | Design alkaline battery pack frame | 2d? | 2006-05-09 | 2006-05-11 | 51 | 46.5d | 11d |  | Brett [50%] | 8h |
| 35 | 1.8.1.2 | Fabricate internal frame and mounts | 4d? | 2006-06-12 | 2006-06-15 | 34, 30 | 25d |  |  | John [25%] | 8h |
| 36 | 1.8.1.3 | Machine Housing | 20d | 2006-04-18 | 2006-05-15 |  | 34d | 0d | start no earlier than 2006-04-18 |  |  |
| 37 | 1.8.1.4 | QC machine work and assemble | 4d? | 2006-05-16 | 2006-05-19 | 36 | 34d | 0d | start no earlier than 2006-04-18 | John [25%] | 8h |
| 38 | 1.8.1.5 | Helium Leak test | 2d? | 2006-05-22 | 2006-05-23 | 37 | 40d | 0d |  | John [25%] | 4h |
| 39 | 1.8.1.6 | Mount on Rover | 2d? | 2006-05-24 | 2006-05-25 | 38 | 40d |  |  | John [25%] | 4h |
| 40 | 1.8.2 | **MVC Sphere** | 34d? | 2006-04-18 | 2006-06-02 |  | 34d |  |  |  | 36h |
| 41 | 1.8.2.1 | Design internal chassis for MVC | 2d? | 2006-04-24 | 2006-04-26 |  | 61.5d |  |  | Brett [50%] | 8h |
| 42 | 1.8.2.2 | Design Seacon plugs | 1d? | 2006-04-24 | 2006-04-25 |  | 61.5d | 0d |  | Brett | 8h |
| 43 | 1.8.2.3 | Machine plugs | 1d? | 2006-04-25 | 2006-04-26 | 42 | 61.5d |  |  |  |  |
| 44 | 1.8.2.4 | Machine Housing | 20d | 2006-04-18 | 2006-05-15 |  | 38d | 4d | start no earlier than 2006-04-18 |  |  |
| 45 | 1.8.2.5 | QC machine work and assemble | 4d? | 2006-05-22 | 2006-05-25 | 44, 37 | 34d | 0d |  | John [25%] | 8h |
| 46 | 1.8.2.6 | Helium leak test | 2d? | 2006-05-26 | 2006-05-29 | 45 | 34d | 0d |  | John [25%] | 4h |
| 47 | 1.8.2.7 | Mount on Rover | 4d? | 2006-05-30 | 2006-06-02 | 46 | 34d |  |  | John [25%] | 8h |
| 48 | 1.8.3 | **Motor controller** | 42.5d? | 2006-04-24 | 2006-06-21 |  | 0d |  |  |  | 160h |
| 49 | 1.8.3.1 | Design motor controller housings | 6d? | 2006-04-24 | 2006-05-04 |  | 0d |  |  | Brett [50%] | 24h |
| 50 | 1.8.3.2 | Confirm design with FEA | 1d? | 2006-05-04 | 2006-05-05 | 49 | 0d |  |  | Brett; Jon | 16h |
| 51 | 1.8.3.3 | Generate machine prints for Ti parts | 2d? | 2006-05-05 | 2006-05-09 | 50 | 0d |  |  | Brett [50%] | 8h |
| 52 | 1.8.3.4 | Drawing check | 1d? | 2006-05-09 | 2006-05-10 | 51 | 0d |  |  | Jon | 8h |
| 53 | 1.8.3.5 | Machine parts | 15d? | 2006-05-10 | 2006-05-31 | 52 | 0d |  |  |  |  |
| 54 | 1.8.3.6 | QC parts and assemble | 1d? | 2006-05-31 | 2006-06-01 | 53 | 0d |  |  | Brett; John | 16h |
| 55 | 1.8.3.7 | Pressure check | 1d? | 2006-06-01 | 2006-06-02 | 54 | 0d |  |  | Jim | 8h |
| 56 | 1.8.3.8 | Electronics Assembly | 1d? | 2006-06-02 | 2006-06-05 | 55 | 0d |  |  | Paul | 8h |
| 57 | 1.8.3.9 | Final assembly, He leak test | 4d? | 2006-06-05 | 2006-06-09 | 56 | 0d |  |  | John [25%] | 8h |
| 58 | 1.8.3.10 | Mount on Rover | 4d? | 2006-06-09 | 2006-06-15 | 57 | 0d |  |  | John [25%] | 8h |
| 59 | 1.8.3.11 | Design Ti sphere mounting brackets | 4d? | 2006-04-24 | 2006-04-28 |  | 59.5d |  |  | John [25%] | 8h |

| ID | WBS | Task | Type | Duration | Start | Finish | Predecessors | Total slack | Free slack | Constraint | Resources | Work |
| --- | --- | --- | --- | --- | --- | --- | --- | --- | --- | --- | --- | --- |
| 60 | 1.8.3.12 | **Motion monitoring data logger** |  | 7d? | 2006-05-09 | 2006-05-18 |  | 45.5d |  |  |  | 32h |
| 61 | 1.8.3.12.1 | Confirm specs with Andy |  | 2d? | 2006-05-09 | 2006-05-11 | 51 | 45.5d | 0d |  | Brett [50%] | 8h |
| 62 | 1.8.3.12.2 | Program and build up system |  | 1d? | 2006-05-11 | 2006-05-12 | 61 | 45.5d | 0d |  | Brett; Andy | 16h |
| 63 | 1.8.3.12.3 | Mount to Rover |  | 4d? | 2006-05-12 | 2006-05-18 | 62 | 45.5d |  |  | John [25%] | 8h |
| 64 | 1.8.3.13 | **Homer transponder** |  | 42.5d? | 2006-04-24 | 2006-06-21 |  | 21.5d |  |  |  | 16h |
| 65 | 1.8.3.13.1 | Check out deep homer from DMO |  | 1d? | 2006-04-24 | 2006-04-25 |  | 62.5d |  |  | Brett | 8h |
| 66 | 1.8.3.13.2 | Fabricate bracket and mount Homer |  | 4d? | 2006-06-15 | 2006-06-21 | 58 | 0d |  |  | John [25%] | 8h |
| 67 | 1.9 | Design lifting sling/eye |  | 4d? | 2006-06-21 | 2006-06-27 | 66 | 0d |  |  | John [25%] | 8h |
| 68 | 1.10 | Remount floatation blocks |  | 2d? | 2006-06-27 | 2006-06-29 | 67 | 0d |  |  | John [25%] | 4h |
| 69 | 1.11 | Design brackets for A-modem |  | 0.5d? | 2006-06-29 | 2006-06-29 | 68 | 0d |  |  | Doug | 4h |
| 70 | 1.12 | Design brackets for current meter |  | 1d? | 2006-06-30 | 2006-06-30 | 69 | 0d |  |  | Doug | 8h |
| 71 | 1.13 | Mount Football Floats |  | 4d? | 2006-07-03 | 2006-07-06 | 70 | 0d |  |  | John [25%] | 8h |
| 72 | 1.14 | Measure wet weight |  | 1d? | 2006-07-07 | 2006-07-07 | 71 | 0d |  |  | John; Brett | 16h |
| 73 | 1.15 | Update trim and balance |  | 1d? | 2006-07-10 | 2006-07-10 | 72 | 0d |  |  | Brett [50%] | 4h |
| 74 | 1.16 | Design and order lead ballast |  | 1d? | 2006-07-11 | 2006-07-11 | 73 | 0d |  |  | Brett [50%] | 4h |
| 75 | 2 | **Testing** |  | 34d? | 2006-06-05 | 2006-07-20 |  | 0d |  |  |  | 36h |
| 76 | 2.1 | Lab Tests |  | 2d? | 2006-06-05 | 2006-06-06 |  | 32d |  | start no earlier than 2006-06-05 | Doug [50%] | 8h |
| 77 | 2.2 | Tank Testing |  | 1d? | 2006-07-12 | 2006-07-12 | 74 | 0d |  | start no earlier than 2006-06-07 | Doug [50%] | 4h |
| 78 | 2.3 | Ready for Sea Tests | milestone | 0d | 2006-07-12 | 2006-07-12 | 77 | 0d |  |  |  |  |
| 79 | 2.4 | Pt. Lobos |  | 4d? | 2006-07-13 | 2006-07-18 | 78 | 0d |  | finish no earlier than 2006-06-19 | Doug [50%] | 16h |
| 80 | 2.5 | Upgrades/Rework |  | 1d? | 2006-07-19 | 2006-07-19 | 79 | 0d |  |  | Doug [50%] | 4h |
| 81 | 2.6 | Final pool test |  | 1d? | 2006-07-20 | 2006-07-20 | 80 | 0d |  |  | Doug [50%] | 4h |
| 82 | 3 | Ready for shipment | milestone | 0d | 2006-07-21 | 2006-07-21 |  | 0d |  | start no earlier than 2006-07-21 |  |  |
