# Rover Mechanical Tasks Fall 06 de-scope

Schedule from MS Project, 2006-04-18 to 2006-12-04, A marks actual dates.
MBARI

## Calendars

- Standard: Mon-Fri 08:00-12:00, 13:00-17:00; Sat-Sun off.

## Resources

| Resource |
| --- |
| D |
| Doug |
| John |
| Brett |
| Fred |
| Jon |
| S |
| Machine Shop |
| Ed |
| Jim |
| Paul |
| Andy |
| -+ |
| MS |
| Tom |
| Smith Lab |
| Brett John |
| John Brett |

## Schedule

| ID | WBS | Task | Type | Duration | Start | Finish | Predecessors | Complete | Constraint | Resources | Work | Actual work |
| --- | --- | --- | --- | --- | --- | --- | --- | --- | --- | --- | --- | --- |
| 1 | 1 | **Atlantis Cruise Tasks** |  | 103d? | 2006-04-18 A | 2006-09-07 A |  | 100% |  |  | 527h | 527h |
| 2 | 1.1 | **Weight drop** |  | 27.5d? | 2006-04-24 A | 2006-05-31 A |  | 100% |  |  | 36h | 36h |
| 3 | 1.1.1 | Modify weight drop assembly |  | 8d | 2006-04-24 A | 2006-05-04 A |  | 100% |  | John [25%] | 16h | 16h |
| 4 | 1.1.2 | order iron rod and hoops |  | 1d? | 2006-05-04 A | 2006-05-05 A | 3 | 100% |  | Brett [50%] | 4h | 4h |
| 5 | 1.1.3 | ship material |  | 10d | 2006-05-05 A | 2006-05-19 A | 4 | 100% |  |  |  |  |
| 6 | 1.1.4 | Cut rod and hoops |  | 2d? | 2006-05-19 A | 2006-05-23 A | 5 | 100% |  | John [25%] | 4h | 4h |
| 7 | 1.1.5 | weld hoops to weights |  | 2d? | 2006-05-23 A | 2006-05-25 A | 6 | 100% |  | John [25%] | 4h | 4h |
| 8 | 1.1.6 | Install weight |  | 4d? | 2006-05-25 A | 2006-05-31 A | 7 | 100% |  | John [25%] | 8h | 8h |
| 9 | 1.2 | **Track tensioner** |  | 22d? | 2006-04-24 A | 2006-05-23 A |  | 100% |  |  | 20h | 20h |
| 10 | 1.2.1 | Fabricate Ti springs |  | 2d? | 2006-04-24 A | 2006-04-25 A |  | 100% |  | Fred | 16h | 16h |
| 11 | 1.2.2 | Receive springs from SIO | milestone | 0d | 2006-05-22 A | 2006-05-22 A |  | 100% | start no earlier than 2006-05-22 |  |  |  |
| 12 | 1.2.3 | Install springs and test |  | 2d? | 2006-05-22 A | 2006-05-23 A | 11 | 100% |  | John [25%] | 4h | 4h |
| 13 | 1.3 | **Argos transmitter** |  | 52d? | 2006-04-24 A | 2006-07-04 A |  | 100% |  |  | 8h | 8h |
| 14 | 1.3.1 | set up account |  | 1d? | 2006-04-24 A | 2006-04-25 A |  | 100% |  | Brett [50%] | 4h | 4h |
| 15 | 1.3.2 | Design and build a bracket |  | 2d? | 2006-07-03 A | 2006-07-04 A | 70 | 100% |  | John [25%] | 4h | 4h |
| 16 | 1.4 | **Spar Buoy** |  | 29d? | 2006-04-24 A | 2006-06-01 A |  | 100% |  |  | 96h | 96h |
| 17 | 1.4.1 | Update model with SIO Spar Buoy components |  | 1d? | 2006-04-24 A | 2006-04-25 A |  | 100% |  | Brett [50%] | 4h | 4h |
| 18 | 1.4.2 | ship components from SIO to MBARI |  | 10d? | 2006-05-15 A | 2006-05-26 A |  | 100% | start no earlier than 2006-05-15 | Fred | 80h | 80h |
| 19 | 1.4.3 | Assemble spar buoy assembly |  | 4d? | 2006-05-29 A | 2006-06-01 A | 18 | 100% |  | John [25%] | 8h | 8h |
| 20 | 1.4.4 | confirm Atlantis can receive 159.480 MHz |  | 0.25d? | 2006-04-24 A | 2006-04-24 A |  | 100% |  | Brett | 2h | 2h |
| 21 | 1.4.5 | order connector rope |  | 0.5d? | 2006-04-24 A | 2006-04-24 A |  | 100% |  | Brett [50%] | 2h | 2h |
| 22 | 1.5 | **Oil compensator** |  | 20d? | 2006-05-01 A | 2006-05-26 A |  | 100% |  |  | 12h | 12h |
| 23 | 1.5.1 | Fabricate parts |  | 14d | 2006-05-01 A | 2006-05-18 A |  | 100% | start no earlier than 2006-05-01 |  |  |  |
| 24 | 1.5.2 | Build up, fill and test |  | 2d? | 2006-05-19 A | 2006-05-22 A | 23, 3 | 100% |  | John [25%] | 4h | 4h |
| 25 | 1.5.3 | Assemble plumbing |  | 2d? | 2006-05-23 A | 2006-05-24 A | 24 | 100% |  | John [25%] | 4h | 4h |
| 26 | 1.5.4 | Mount on Rover |  | 2d? | 2006-05-25 A | 2006-05-26 A | 25 | 100% |  | John [25%] | 4h | 4h |

| ID | WBS | Task | Duration | Start | Finish | Predecessors | Complete | Constraint | Resources | Work | Actual work |
| --- | --- | --- | --- | --- | --- | --- | --- | --- | --- | --- | --- |
| 27 | 1.6 | **Shipboard cradle** | 10d? | 2006-05-29 A | 2006-06-09 A |  | 100% |  |  | 27h | 27h |
| 28 | 1.6.1 | Design cradle | 0.5d? | 2006-05-29 A | 2006-05-29 A | 26 | 100% |  | Brett; John | 8h | 8h |
| 29 | 1.6.2 | order parts | 1.5d? | 2006-05-29 A | 2006-05-30 A | 28 | 100% |  | John [25%] | 3h | 3h |
| 30 | 1.6.3 | fabricate and install | 8d? | 2006-05-31 A | 2006-06-09 A | 29 | 100% |  | John [25%] | 16h | 16h |
| 31 | 1.7 | CDR prep | 2d? | 2006-04-24 A | 2006-04-26 A |  | 100% |  | Brett [50%] | 8h | 8h |
| 32 | 1.8 | **Pressure Housings** | 46.5d? | 2006-04-18 A | 2006-06-21 A |  | 100% |  |  | 228h | 228h |
| 33 | 1.8.1 | **Battery Sphere** | 43d? | 2006-04-18 A | 2006-06-15 A |  | 100% |  |  | 32h | 32h |
| 34 | 1.8.1.1 | Design alkaline battery pack frame | 2d? | 2006-05-09 A | 2006-05-11 A | 51 | 100% |  | Brett [50%] | 8h | 8h |
| 35 | 1.8.1.2 | Fabricate internal frame and mounts | 4d? | 2006-06-12 A | 2006-06-15 A | 34, 30 | 100% |  | John [25%] | 8h | 8h |
| 36 | 1.8.1.3 | Machine Housing | 20d | 2006-04-18 A | 2006-05-15 A |  | 100% | start no earlier than 2006-04-18 |  |  |  |
| 37 | 1.8.1.4 | QC machine work and assemble | 4d? | 2006-05-16 A | 2006-05-19 A | 36 | 100% | start no earlier than 2006-04-18 | John [25%] | 8h | 8h |
| 38 | 1.8.1.5 | Helium Leak test | 2d? | 2006-05-22 A | 2006-05-23 A | 37 | 100% |  | John [25%] | 4h | 4h |
| 39 | 1.8.1.6 | Mount on Rover | 2d? | 2006-05-24 A | 2006-05-25 A | 38 | 100% |  | John [25%] | 4h | 4h |
| 40 | 1.8.2 | **MVC Sphere** | 34d? | 2006-04-18 A | 2006-06-02 A |  | 100% |  |  | 36h | 36h |
| 41 | 1.8.2.1 | Design internal chassis for MVC | 2d? | 2006-04-24 A | 2006-04-26 A |  | 100% |  | Brett [50%] | 8h | 8h |
| 42 | 1.8.2.2 | Design Seacon plugs | 1d? | 2006-04-24 A | 2006-04-25 A |  | 100% |  | Brett | 8h | 8h |
| 43 | 1.8.2.3 | Machine plugs | 1d? | 2006-04-25 A | 2006-04-26 A | 42 | 100% |  |  |  |  |
| 44 | 1.8.2.4 | Machine Housing | 20d | 2006-04-18 A | 2006-05-15 A |  | 100% | start no earlier than 2006-04-18 |  |  |  |
| 45 | 1.8.2.5 | QC machine work and assemble | 4d? | 2006-05-22 A | 2006-05-25 A | 44, 37 | 100% |  | John [25%] | 8h | 8h |
| 46 | 1.8.2.6 | Helium leak test | 2d? | 2006-05-26 A | 2006-05-29 A | 45 | 100% |  | John [25%] | 4h | 4h |
| 47 | 1.8.2.7 | Mount on Rover | 4d? | 2006-05-30 A | 2006-06-02 A | 46 | 100% |  | John [25%] | 8h | 8h |
| 48 | 1.8.3 | **Motor controller** | 42.5d? | 2006-04-24 A | 2006-06-21 A |  | 100% |  |  | 160h | 160h |
| 49 | 1.8.3.1 | Design motor controller housings | 6d? | 2006-04-24 A | 2006-05-04 A |  | 100% |  | Brett [50%] | 24h | 24h |
| 50 | 1.8.3.2 | Confirm design with FEA | 1d? | 2006-05-04 A | 2006-05-05 A | 49 | 100% |  | Brett; Jon | 16h | 16h |
| 51 | 1.8.3.3 | Generate machine prints for Ti parts | 2d? | 2006-05-05 A | 2006-05-09 A | 50 | 100% |  | Brett [50%] | 8h | 8h |
| 52 | 1.8.3.4 | Drawing check | 1d? | 2006-05-09 A | 2006-05-10 A | 51 | 100% |  | Jon | 8h | 8h |
| 53 | 1.8.3.5 | Machine parts | 15d? | 2006-05-10 A | 2006-05-31 A | 52 | 100% |  |  |  |  |
| 54 | 1.8.3.6 | QC parts and assemble | 1d? | 2006-05-31 A | 2006-06-01 A | 53 | 100% |  | Brett; John | 16h | 16h |
| 55 | 1.8.3.7 | Pressure check | 1d? | 2006-06-01 A | 2006-06-02 A | 54 | 100% |  | Jim | 8h | 8h |
| 56 | 1.8.3.8 | Electronics Assembly | 1d? | 2006-06-02 A | 2006-06-05 A | 55 | 100% |  | Paul | 8h | 8h |
| 57 | 1.8.3.9 | Final assembly, He leak test | 4d? | 2006-06-05 A | 2006-06-09 A | 56 | 100% |  | John [25%] | 8h | 8h |
| 58 | 1.8.3.10 | Mount on Rover | 4d? | 2006-06-09 A | 2006-06-15 A | 57 | 100% |  | John [25%] | 8h | 8h |
| 59 | 1.8.3.11 | Design Ti sphere mounting brackets | 4d? | 2006-04-24 A | 2006-04-28 A |  | 100% |  | John [25%] | 8h | 8h |

| ID | WBS | Task | Type | Duration | Start | Finish | Predecessors | Complete | Constraint | Resources | Work | Actual work |
| --- | --- | --- | --- | --- | --- | --- | --- | --- | --- | --- | --- | --- |
| 60 | 1.8.3.12 | **Motion monitoring data logger** |  | 7d? | 2006-05-09 A | 2006-05-18 A |  | 100% |  |  | 32h | 32h |
| 61 | 1.8.3.12.1 | Confirm specs with Andy |  | 2d? | 2006-05-09 A | 2006-05-11 A | 51 | 100% |  | Brett [50%] | 8h | 8h |
| 62 | 1.8.3.12.2 | Program and build up system |  | 1d? | 2006-05-11 A | 2006-05-12 A | 61 | 100% |  | Brett; Andy | 16h | 16h |
| 63 | 1.8.3.12.3 | Mount to Rover |  | 4d? | 2006-05-12 A | 2006-05-18 A | 62 | 100% |  | John [25%] | 8h | 8h |
| 64 | 1.8.3.13 | **Homer transponder** |  | 42.5d? | 2006-04-24 A | 2006-06-21 A |  | 100% |  |  | 16h | 16h |
| 65 | 1.8.3.13.1 | Check out deep homer from DMO |  | 1d? | 2006-04-24 A | 2006-04-25 A |  | 100% |  | Brett | 8h | 8h |
| 66 | 1.8.3.13.2 | Fabricate bracket and mount Homer |  | 4d? | 2006-06-15 A | 2006-06-21 A | 58 | 100% |  | John [25%] | 8h | 8h |
| 67 | 1.9 | Design lifting sling/eye |  | 4d? | 2006-06-21 A | 2006-06-27 A | 66 | 100% |  | John [25%] | 8h | 8h |
| 68 | 1.10 | Remount floatation blocks |  | 2d? | 2006-06-27 A | 2006-06-29 A | 67 | 100% |  | John [25%] | 4h | 4h |
| 69 | 1.11 | Design brackets for A-modem |  | 0.5d? | 2006-06-29 A | 2006-06-29 A | 68 | 100% |  | Doug | 4h | 4h |
| 70 | 1.12 | Design brackets for current meter |  | 1d? | 2006-06-30 A | 2006-06-30 A | 69 | 100% |  | Doug | 8h | 8h |
| 71 | 1.13 | Mount Football Floats |  | 4d? | 2006-07-03 A | 2006-07-06 A | 70 | 100% |  | John [25%] | 8h | 8h |
| 72 | 1.14 | Measure wet weight |  | 1d? | 2006-07-07 A | 2006-07-07 A | 71 | 100% |  | John; Brett | 16h | 16h |
| 73 | 1.15 | Update trim and balance |  | 1d? | 2006-07-10 A | 2006-07-10 A | 72 | 100% |  | Brett [50%] | 4h | 4h |
| 74 | 1.16 | Design and order lead ballast |  | 1d? | 2006-07-11 A | 2006-07-11 A | 73 | 100% |  | Brett [50%] | 4h | 4h |
| 75 | 1.17 | **Testing** |  | 34d? | 2006-06-05 A | 2006-07-21 A |  | 100% |  |  | 36h | 36h |
| 76 | 1.17.1 | Lab Tests |  | 2d? | 2006-06-05 A | 2006-06-06 A |  | 100% | start no earlier than 2006-06-05 | Doug [50%] | 8h | 8h |
| 77 | 1.17.2 | Tank Testing |  | 1d? | 2006-07-12 A | 2006-07-12 A | 74 | 100% | start no earlier than 2006-06-07 | Doug [50%] | 4h | 4h |
| 78 | 1.17.3 | Ready for Sea Tests | milestone | 0d | 2006-07-12 A | 2006-07-12 A | 77 | 100% |  |  |  |  |
| 79 | 1.17.4 | Pt. Lobos |  | 4d? | 2006-07-13 A | 2006-07-18 A | 78 | 100% | finish no earlier than 2006-06-19 | Doug [50%] | 16h | 16h |
| 80 | 1.17.5 | Upgrades/Rework |  | 1d? | 2006-07-19 A | 2006-07-19 A | 79 | 100% |  | Doug [50%] | 4h | 4h |
| 81 | 1.17.6 | Final pool test |  | 1d? | 2006-07-20 A | 2006-07-20 A | 80 | 100% |  | Doug [50%] | 4h | 4h |
| 82 | 1.17.7 | Ready for shipment | milestone | 0d | 2006-07-21 A | 2006-07-21 A |  | 100% | start no earlier than 2006-07-21 |  |  |  |
| 83 | 1.18 | Atlantis Cruise |  | 23d | 2006-08-08 A | 2006-09-07 A |  | 100% | start no earlier than 2006-08-08 |  |  |  |

| ID | WBS | Task | Duration | Start | Finish | Predecessors | Complete | Remaining | Total slack | Free slack | Constraint | Resources | Work | Actual work |
| --- | --- | --- | --- | --- | --- | --- | --- | --- | --- | --- | --- | --- | --- | --- |
| 84 | 2 | **Flyer Cruise Tasks** | 160.5d? | 2006-04-24 A | 2006-12-04 |  | 44% | 89.22d? | 0d |  |  |  | 509.6h | 162.4h |
| 85 | 2.1 | **Design** | 21d? | 2006-10-02 A | 2006-10-30 |  | 96% | 0.93d? | 24.5d |  |  |  | 144h | 137.6h |
| 86 | 2.1.1 | Design Racks | 8d? | 2006-10-02 A | 2006-10-18 A |  | 100% |  |  |  | finish no earlier than 2006-10-18 | Brett | 64h | 64h |
| 87 | 2.1.2 | Design Respirometers | 8d? | 2006-10-03 A | 2006-10-27 | 86 | 90% | 0.8d? | 25.5d |  | finish no earlier than 2006-10-18 | Brett | 64h | 57.6h |
| 88 | 2.1.3 | Clean up Rover Drawings | 2d? | 2006-10-04 A | 2006-10-30 A | 87 | 100% |  |  |  | finish no earlier than 2006-10-18 | John | 16h | 16h |
| 89 | 2.2 | CDR | 5d | 2006-10-12 A | 2006-10-18 A |  | 100% |  |  |  |  |  |  |  |
| 90 | 2.3 | **Complete Drawing package for shop** | 3.7d? | 2006-10-19 A | 2006-10-24 |  | 5% | 3.5d? | 28.8d |  |  |  | 63.2h | 4h |
| 91 | 2.3.1 | **Rack drawings** | 2d? | 2006-10-19 | 2006-10-20 |  |  |  | 8.3d |  |  |  | 28h |  |
| 92 | 2.3.1.1 | Frame | 0.5d? | 2006-10-19 | 2006-10-19 | 89 |  |  | 29d | 0d |  | John | 4h |  |
| 93 | 2.3.1.2 | I-beam blocks | 0.5d? | 2006-10-19 | 2006-10-19 | 92 |  |  | 29d | 0d |  | John | 4h |  |
| 94 | 2.3.1.3 | **Motor assembly** | 1d? | 2006-10-19 | 2006-10-19 |  |  |  | 8.3d |  |  |  | 8h |  |
| 95 | 2.3.1.3.1 | finish output shaft | 0.5d? | 2006-10-19 | 2006-10-19 | 89 |  |  | 8.3d | 0d |  | Brett | 4h |  |
| 96 | 2.3.1.3.2 | other | 0.5d? | 2006-10-19 | 2006-10-19 | 95 |  |  | 8.3d | 0d |  | Brett | 4h |  |
| 97 | 2.3.1.4 | **Leadscrew assembly** | 1d? | 2006-10-20 | 2006-10-20 |  |  |  | 26.8d |  |  |  | 8h |  |
| 98 | 2.3.1.4.1 | Leadscrew mods | 0.5d? | 2006-10-20 | 2006-10-20 | 96 |  |  | 26.8d | 0d |  | Brett | 4h |  |
| 99 | 2.3.1.4.2 | bearing support details | 0.5d? | 2006-10-20 | 2006-10-20 | 98 |  |  | 26.8d | 0d |  | Brett | 4h |  |
| 100 | 2.3.1.5 | Cart | 0.5d? | 2006-10-20 | 2006-10-20 | 93 |  |  | 29d | 0d |  | John | 4h |  |
| 101 | 2.3.2 | **respirometer drawings** | 3.7d? | 2006-10-19 A | 2006-10-24 |  | 9% | 3.38d? | 28.8d |  |  |  | 35.2h | 4h |
| 102 | 2.3.2.1 | chambers | 0.5d? | 2006-10-19 | 2006-10-19 | 89 |  |  | 29.8d | 0d |  | Brett | 4h |  |
| 103 | 2.3.2.2 | optode | 0.2d? | 2006-10-19 | 2006-10-19 | 102 |  |  | 29.8d | 0d |  | Brett | 1.6h |  |
| 104 | 2.3.2.3 | vents | 1d? | 2006-10-19 | 2006-10-20 | 103 |  |  | 29.8d | 0d |  | Brett | 8h |  |
| 105 | 2.3.2.4 | stirer | 1d? | 2006-10-20 | 2006-10-23 | 104 |  |  | 29.8d |  |  | John | 8h |  |
| 106 | 2.3.2.5 | j-box | 0.5d? | 2006-10-24 A | 2006-10-24 A | 105 | 100% |  |  |  |  | Brett | 4h | 4h |
| 107 | 2.3.2.6 | touchdown switch | 0.5d? | 2006-10-19 | 2006-10-19 | 89 |  |  | 30d | 0d |  | Brett | 4h |  |
| 108 | 2.3.2.7 | chamber knife | 1d? | 2006-10-19 | 2006-10-20 | 107 |  |  | 30d | 0d |  | John [20%] | 1.6h |  |
| 109 | 2.3.2.8 | Pump, plumbing and manifold | 1d? | 2006-10-20 | 2006-10-23 | 108 |  |  | 30d |  |  | John [50%] | 4h |  |
| 110 | 2.4 | Machine parts | 20d | 2006-10-20 | 2006-11-16 | 96 |  |  | 8.3d | 0d |  |  |  |  |
| 111 | 2.5 | Order materials | 1d? | 2006-10-20 A | 2006-10-23 | 100 | 80% | 0.2d? | 29d | 0d |  | John | 8h | 6.4h |
| 112 | 2.6 | Order U/W connectors | 20d | 2006-10-20 A | 2006-11-16 A |  | 100% |  |  |  | start no earlier than 2006-10-20 |  |  |  |

| ID | WBS | Task | Duration | Start | Finish | Predecessors | Complete | Remaining | Total slack | Free slack | Resources | Work | Actual work |
| --- | --- | --- | --- | --- | --- | --- | --- | --- | --- | --- | --- | --- | --- |
| 113 | 2.7 | **Rack Assembly** | 152.2d? | 2006-04-24 A | 2006-11-22 |  | 1% | 150.61d? | 8.3d |  |  | 172.8h | 1.6h |
| 114 | 2.7.1 | **Fab Frame** | 131.5d? | 2006-04-24 A | 2006-10-24 |  | 8% | 120.98d? | 29d |  |  | 20h | 1.6h |
| 115 | 2.7.1.1 | Fab rack mount blocks | 1d? | 2006-10-23 | 2006-10-24 | 111 |  |  | 29d |  | John | 8h |  |
| 116 | 2.7.1.2 | Cut I-beams | 0.4d? | 2006-04-24 A | 2006-04-24 |  | 50% | 0.2d? | 157.1d | 0d | John | 3.2h | 1.6h |
| 117 | 2.7.1.3 | mount blocks | 0.2d? | 2006-04-24 | 2006-04-25 | 116 |  |  | 156.6d | 0d | John | 1.6h |  |
| 118 | 2.7.1.4 | fab tube mounts | 0.5d? | 2006-04-25 | 2006-04-25 | 117 |  |  | 156.6d | 0d | John | 4h |  |
| 119 | 2.7.1.5 | square up and assemble frame | 0.4d? | 2006-04-25 | 2006-04-25 | 118 |  |  | 156.6d | 0d | John | 3.2h |  |
| 120 | 2.7.2 | **Cart** | 148d? | 2006-04-26 | 2006-11-17 |  |  |  | 10.5d |  |  | 15.2h |  |
| 121 | 2.7.2.1 | Cut and clean up shafts | 0.2d? | 2006-04-26 | 2006-04-26 | 119 |  |  | 156.6d | 0d | John | 1.6h |  |
| 122 | 2.7.2.2 | fab wheels | 0.5d? | 2006-04-26 | 2006-04-26 | 121 |  |  | 156.6d | 0d | John | 4h |  |
| 123 | 2.7.2.3 | fab and mount sliders | 0.2d? | 2006-04-26 | 2006-04-26 | 122 |  |  | 156.6d | 146.1d | John | 1.6h |  |
| 124 | 2.7.2.4 | assemble cart | 1d? | 2006-11-17 | 2006-11-17 | 123, 110 |  |  | 10.5d |  | John | 8h |  |
| 125 | 2.7.3 | **Motor Assembly** | 150.7d? | 2006-04-24 | 2006-11-20 |  |  |  | 9.8d |  |  | 41.6h |  |
| 126 | 2.7.3.1 | prep motors for oil | 0.5d? | 2006-10-23 | 2006-10-23 | 99 |  |  | 26.8d | 18.5d | John | 4h |  |
| 127 | 2.7.3.2 | wireup and build motor assembly | 0.5d? | 2006-11-17 | 2006-11-17 | 126, 110 |  |  | 8.3d | 0d | Brett | 4h |  |
| 128 | 2.7.3.3 | add inserts and standoffs to amp endcap | 0.2d? | 2006-11-17 | 2006-11-17 | 127 |  |  | 8.3d | 0d | John | 1.6h |  |
| 129 | 2.7.3.4 | install and wireup ez-servo | 0.5d? | 2006-11-17 | 2006-11-20 | 128 |  |  | 8.3d | 0d | Tom | 4h |  |
| 130 | 2.7.3.5 | assemble comp plumbing to motor block | 0.5d? | 2006-11-20 | 2006-11-20 | 129 |  |  | 8.3d | 0d | Jim | 4h |  |
| 131 | 2.7.3.6 | Modify leadscrew | 1d? | 2006-04-24 | 2006-04-25 |  |  |  | 159d |  | John | 8h |  |
| 132 | 2.7.3.7 | assemble leadscrew | 1d? | 2006-04-24 | 2006-04-25 |  |  |  | 159d |  | John; Brett | 16h |  |
| 133 | 2.7.4 | Rack assembly | 1d? | 2006-11-20 | 2006-11-21 | 130 |  |  | 8.3d | 0d | John; Brett | 16h |  |
| 134 | 2.7.5 | Final assembly | 0.5d? | 2006-11-21 | 2006-11-22 | 133 |  |  | 8.3d |  | John; Brett | 8h |  |
| 135 | 2.7.6 | **Touchdown switch** | 4d? | 2006-04-24 | 2006-04-27 |  |  |  | 156.5d |  |  | 72h |  |
| 136 | 2.7.6.1 | Assemble | 1d? | 2006-04-24 | 2006-04-25 |  |  |  | 158d | 0d | John | 8h |  |
| 137 | 2.7.6.2 | Assemble and test plunger | 1d? | 2006-04-25 | 2006-04-26 | 136 |  |  | 158d |  | John | 8h |  |

| ID | WBS | Task | Duration | Start | Finish | Predecessors | Complete | Remaining | Total slack | Free slack | Constraint | Resources | Work | Actual work |
| --- | --- | --- | --- | --- | --- | --- | --- | --- | --- | --- | --- | --- | --- | --- |
| 138 | 2.7.6.3 | **Vents** | 4d? | 2006-04-24 | 2006-04-27 |  |  |  | 156.5d |  |  |  | 56h |  |
| 139 | 2.7.6.3.1 | assemble parts for 1 vent | 2d? | 2006-04-24 | 2006-04-25 |  |  |  | 157.5d | 0d |  | Jim | 16h |  |
| 140 | 2.7.6.3.2 | fill with oil and test | 0.5d? | 2006-04-26 | 2006-04-26 | 139 |  |  | 157.5d | 0d |  | Jim | 4h |  |
| 141 | 2.7.6.3.3 | cold room test | 0.5d? | 2006-04-26 | 2006-04-26 | 140 |  |  | 157.5d |  |  | Jim | 4h |  |
| 142 | 2.7.6.3.4 | **Hall effect switches (3)** | 4d? | 2006-04-24 | 2006-04-27 |  |  |  | 156.5d |  |  |  | 32h |  |
| 143 | 2.7.6.3.4.1 | mold switches | 3d? | 2006-04-24 | 2006-04-26 |  |  |  | 156.5d | 0d |  | Jim | 24h |  |
| 144 | 2.7.6.3.4.2 | assemble wiring and plumbing | 1d? | 2006-04-27 | 2006-04-27 | 143 |  |  | 156.5d |  |  | Jim | 8h |  |
| 145 | 2.8 | **Other Tasks** | 38.5d? | 2006-10-11 A | 2006-12-04 |  | 38% | 23.83d? | 0d |  |  |  | 33.6h | 12.8h |
| 146 | 2.8.1 | Re-assemble Strb drive motor and both amps | 1d? | 2006-11-16 A | 2006-11-17 |  | 85% | 0.15d? | 5.8d | 0d |  | John | 8h | 6.8h |
| 147 | 2.8.2 | Modify drop weight jack | 1d? | 2006-10-11 A | 2006-10-11 |  | 75% | 0.25d? | 36.3d | 0d |  | Jim | 8h | 6h |
| 148 | 2.8.3 | Re-load drop weight | 0.2d? | 2006-10-12 | 2006-10-12 | 147 |  |  | 36.3d | 0d |  | Jim | 1.6h |  |
| 149 | 2.8.4 | Buy, mount and wireup camera(s) | 1d? | 2006-10-12 | 2006-10-13 | 148 |  |  | 36.3d |  |  | Jim | 8h |  |
| 150 | 2.8.5 | Assemble and test acoustic modem | 0.5d? | 2006-12-04 | 2006-12-04 |  |  |  | 0d |  | as late as possible | Brett | 4h |  |
| 151 | 2.8.6 | Assembe two more oil compensators, mount, fill and bleed | 0.5d? | 2006-11-17 | 2006-11-17 | 146 |  |  | 5.8d | 0d |  | John | 4h |  |
| 152 | 2.9 | Tank tests | 3d | 2006-11-17 | 2006-11-22 | 151 |  |  | 5.8d | 0d |  | John; Brett | 48h |  |
| 153 | 2.10 | Rework | 1d? | 2006-11-22 | 2006-11-23 | 152 |  |  | 5.8d | 0d |  | John; Brett | 16h |  |
| 154 | 2.11 | Retest in tank | 1d? | 2006-11-23 | 2006-11-24 | 153 |  |  | 5.8d |  |  | John; Brett | 16h |  |
| 155 | 2.12 | Pt. Lobos Cruise | 0.5d? | 2006-12-04 | 2006-12-04 |  |  |  | 0d |  | start no earlier than 2006-12-04 | Brett; John | 8h |  |
