# Rover

Schedule from MS Project, 2005-08-02 to 2005-08-15.
MBARI

## Calendars

- Standard: Mon-Fri 08:00-12:00, 13:00-17:00; Sat-Sun off.

## Schedule

| ID | Task | Duration | Start | Finish | Predecessors | Baseline start | Baseline finish | Baseline duration | Total slack | Free slack | Constraint | Deadline |
| --- | --- | --- | --- | --- | --- | --- | --- | --- | --- | --- | --- | --- |
| 1 | Current Meter Cycle | 60min | 2005-08-02 08:00 | 2005-08-02 09:00 |  | 2005-08-02 08:00 | 2005-08-02 09:00 | 60min | -5.9d | 0d |  |  |
| 2 | Transit Time | 5min | 2005-08-02 09:00 | 2005-08-02 09:05 | 1 | 2005-08-02 09:00 | 2005-08-02 09:05 | 5min | -5.9d | 0d | start no earlier than 2005-08-02 08:00 | 2005-08-02 17:00 |
| 3 | Dust Settle Period | 60min | 2005-08-02 09:05 | 2005-08-02 10:05 | 2 | 2005-08-02 09:05 | 2005-08-02 10:05 | 60min | -5.9d | 0d |  |  |
| 4 | Run Scan | 240min | 2005-08-02 10:05 | 2005-08-02 15:05 | 3 | 2005-08-02 10:05 | 2005-08-02 15:05 | 240min | -5.9d | 0d |  |  |
| 5 | Lower Respirometer Rack | 5min | 2005-08-02 15:05 | 2005-08-02 15:10 | 4 | 2005-08-02 15:05 | 2005-08-02 15:10 | 5min | -5.9d | 0d |  |  |
| 6 | Respirometry | 4320min | 2005-08-02 15:10 | 2005-08-15 16:10 | 5 | 2005-08-02 15:10 | 2005-08-15 16:10 | 4320min | -5.9d | 0d | finish no earlier than 2005-08-15 16:10 | 2005-08-05 17:00 |
| 7 | Video | 5min | 2005-08-02 15:10 | 2005-08-02 15:15 |  | 2005-08-02 15:10 | 2005-08-02 15:15 | 5min | 9.11d |  | start no earlier than 2005-08-02 15:10 |  |
